# APQP计划一

Schedule from MS Project, 2002-01-14 to 2002-07-03.
合力

## Calendars

- 标准: Mon-Fri 08:00-12:00, 13:00-17:00; Sat-Sun off. Exceptions (off unless hours are given): 2002-01-19 to 2002-01-20 08:00-12:00, 13:00-17:00, 2002-02-24 08:00-12:00, 13:00-17:00, 2002-04-27 08:00-12:00, 13:00-17:00, 2002-05-25 08:00-12:00, 13:00-17:00, 2002-06-01 08:00-12:00, 13:00-17:00, 2002-06-15 to 2002-06-16 08:00-12:00, 13:00-17:00, 2002-06-23 08:00-12:00, 13:00-17:00, 2002-06-30 08:00-12:00, 13:00-17:00.

## Schedule

| ID | Task | Duration | Start | Finish | Predecessors | Baseline start | Baseline finish | Baseline duration | Total slack | Free slack | Constraint | Text1 |
| --- | --- | --- | --- | --- | --- | --- | --- | --- | --- | --- | --- | --- |
| 1 | 一.计划与确定项目 | 15d | 2002-01-14 | 2002-01-30 |  | 2002-04-15 | 2002-04-26 | 10d | 118d |  | start no earlier than 2002-01-14 |  |
| 2 | 识别顾客需求 | 1d | 2002-01-14 | 2002-01-14 |  | 2002-04-15 | 2002-04-15 | 1d | 132d |  | start no earlier than 2002-01-14 | 姚晓君 |
| 3 | 可行性分析 | 1d | 2002-01-15 | 2002-01-15 |  | 2002-04-15 | 2002-04-16 | 2d | 117d | 0d | start no earlier than 2002-01-15 | 小组 |
| 4 | 成立项目小组 | 1d | 2002-01-16 | 2002-01-16 | 3 |  |  |  | 117d | 0d |  | 项目小组 |
| 5 | 编制APQP实施计划 | 1d | 2002-01-17 | 2002-01-17 | 4 |  |  |  | 117d | 0d |  | 项目小组 |
| 6 | 设计任务书 | 3d | 2002-01-18 | 2002-01-20 | 5 | 2002-04-17 | 2002-04-17 | 1d | 117d | 0d |  | 顾江龙 |
| 7 | 初始材料清单 | 5d | 2002-01-21 | 2002-01-25 | 6 | 2002-04-18 | 2002-04-18 | 1d | 117d | 0d |  | 张燕 |
| 8 | 初始过程流程图 | 4d | 2002-01-28 | 2002-01-31 | 7 | 2002-04-19 | 2002-04-22 | 2d | 117d |  |  | 张燕 |
| 9 | 设备、工装、量具、试验装置初始清单 | 3d | 2002-01-24 | 2002-01-28 |  |  |  |  | 120d |  | start no earlier than 2002-01-24 | 顾江龙 |
| 10 | 产品和过程特殊特性初始清单 | 2d | 2002-01-23 | 2002-01-24 |  | 2002-04-23 | 2002-04-24 | 2d | 122d |  | start no earlier than 2002-01-23 | 顾江龙 |
| 11 | 产品采购计划 | 2d | 2002-01-25 | 2002-01-28 |  |  |  |  | 120d |  | start no earlier than 2002-01-25 | 缪志军 |
| 12 | 产品保证计划 | 1d | 2002-01-28 | 2002-01-28 |  | 2002-04-25 | 2002-04-26 | 2d | 120d |  | start no earlier than 2002-01-28 | 项目小组 |
| 13 | 项目可行性评估 | 1d | 2002-01-29 | 2002-01-29 |  |  |  |  | 119d |  | start no earlier than 2002-01-29 | 项目小组 |
| 14 | 阶段总结和管理者支持 | 1d | 2002-01-30 | 2002-01-30 |  | 2002-04-26 | 2002-04-26 | 1d | 46d | 0d | start no earlier than 2002-01-30 | 项目小组 |
| 15 | 二.产品设计和开发 | 72d | 2002-01-31 | 2002-05-08 | 14 | 2002-04-27 | 2002-05-16 | 15d | 46d |  | finish no earlier than 2002-05-08 |  |
| 16 | DFMEA | 7d | 2002-01-31 | 2002-02-08 |  | 2002-04-27 | 2002-05-06 | 7d | 111d |  | start no earlier than 2002-01-31 | 项目小组 |
| 17 | 图纸绘制 | 9d | 2002-02-04 | 2002-02-14 |  | 2002-04-29 | 2002-05-03 | 5d | 102d | 0d | start no earlier than 2002-02-04 | 顾江龙 |
| 18 | 设计验证 | 3d | 2002-02-15 | 2002-02-19 | 17 | 2002-05-03 | 2002-05-06 | 2d | 102d | 0d |  | 项目小组 |
| 19 | 设计评审 | 2d | 2002-02-20 | 2002-02-21 | 18 | 2002-05-07 | 2002-05-08 | 2d | 102d |  |  | 项目小组 |
| 20 | 样件控制计划 | 11d | 2002-02-20 | 2002-03-05 |  |  |  |  | 93d |  | start no earlier than 2002-02-20 | 项目小组 |
| 21 | 工程样件制造 | 2d | 2002-03-07 | 2002-03-08 |  | 2002-05-09 | 2002-05-13 | 3d | 90d |  | start no earlier than 2002-03-07 | 项目小组 |
| 22 | 材料清单 | 3d | 2002-03-11 | 2002-03-13 |  | 2002-05-10 | 2002-05-14 | 3d | 87d |  | start no earlier than 2002-03-11 | 张燕 |
| 23 | 产品和过程特殊特性清单 | 2d | 2002-03-12 | 2002-03-13 |  | 2002-05-15 | 2002-05-16 | 2d | 55d | 0d | start no earlier than 2002-03-12 | 张燕 |
| 24 | 新设备、工装和设施要求 | 2d | 2002-03-14 | 2002-03-15 | 23 | 2002-05-17 | 2002-05-22 | 4d | 55d | 0d | start no earlier than 2002-03-07 | 张燕 |
| 25 | 新设备、工装和设施采购 | 30d | 2002-03-18 | 2002-04-26 | 24 |  |  |  | 55d |  | start no earlier than 2002-03-07 | 缪志军 |
| 26 | 量具和试验设备要求 | 1d | 2002-03-15 | 2002-03-15 |  | 2002-05-23 | 2002-05-23 | 1d | 85d |  | start no earlier than 2002-03-15 | 张燕 |
| 27 | 量具和试验设备采购 | 10d | 2002-03-15 | 2002-03-28 |  |  |  |  | 76d |  | start no earlier than 2002-03-15 | 缪志军 |
| 28 | 工装（OTS)样件制作、提交（认可） | 3d | 2002-05-06 | 2002-05-08 |  |  |  |  | 46d |  | start no earlier than 2002-05-06 | 顾江龙 |
| 29 | 小组可行性承诺及管理者支持 | 1d | 2002-05-08 | 2002-05-08 |  | 2002-05-24 | 2002-05-24 | 1d | 46d |  | start no earlier than 2002-05-08 | 项目小组 |
| 30 | 三.过程设计及开发 | 32d | 2002-05-09 | 2002-06-17 |  | 2002-05-27 | 2002-06-17 | 19d | 14d |  | start no earlier than 2002-05-09 |  |
| 31 | 包装标准 | 2d | 2002-05-09 | 2002-05-10 |  | 2002-06-01 | 2002-06-01 | 1d | 44d |  | start no earlier than 2002-05-09 | 张燕 |
| 32 | 产品/过程质量体系评审 | 2d | 2002-05-10 | 2002-05-13 |  |  |  |  | 43d |  | start no earlier than 2002-05-10 | 姚晓君 |
| 33 | 过程流程图 | 4d | 2002-05-14 | 2002-05-17 |  | 2002-06-03 | 2002-06-07 | 5d | 39d |  | start no earlier than 2002-05-14 | 张燕 |
| 34 | 场地平面布局图 | 2d | 2002-05-21 | 2002-05-22 |  | 2002-06-05 | 2002-06-06 | 2d | 36d |  | start no earlier than 2002-05-21 | 陆耀平 |
| 35 | 特性矩阵图 | 3d | 2002-05-20 | 2002-05-22 |  |  |  |  | 36d |  | start no earlier than 2002-05-20 | 陆耀平 |
| 36 | PFMEA | 10d | 2002-05-20 | 2002-05-30 |  | 2002-06-01 | 2002-06-13 | 10d | 29d |  | start no earlier than 2002-05-18 | 项目小组 |
| 37 | 试生产控制计划 | 8d | 2002-06-01 | 2002-06-11 |  | 2002-06-04 | 2002-06-13 | 8d | 20d |  | start no earlier than 2002-06-01 | 项目小组 |
| 38 | 工艺过程控制卡 | 8d | 2002-06-13 | 2002-06-20 |  | 2002-06-06 | 2002-06-15 | 8d | 11d |  | start no earlier than 2002-06-13 | 张燕 |
| 39 | 测量系统分析计划 | 2d | 2002-06-13 | 2002-06-14 |  | 2002-06-13 | 2002-06-14 | 2d | 15d | 0d | start no earlier than 2002-06-13 | 郭圣妍 |
| 40 | 初始过程能力研究计划 | 2d | 2002-06-15 | 2002-06-16 | 39 | 2002-06-15 | 2002-06-16 | 2d | 15d |  | start no earlier than 2002-06-15 | 蒋伟东 |
| 41 | 包装规范 | 1d | 2002-06-16 | 2002-06-16 |  | 2002-06-16 | 2002-06-16 | 1d | 15d |  | start no earlier than 2002-06-16 | 张燕 |
| 42 | 阶段总结和管理者支持 | 1d | 2002-06-17 | 2002-06-17 |  | 2002-06-17 | 2002-06-17 | 1d | 14d |  | start no earlier than 2002-06-17 | 项目小组 |
| 43 | 四.产品和过程确认 | 11d | 2002-06-18 | 2002-06-30 |  | 2002-06-18 | 2002-06-28 | 10d | 3d |  | start no earlier than 2002-06-18 |  |
| 44 | 试生产 | 3d | 2002-06-18 | 2002-06-20 |  | 2002-06-18 | 2002-06-18 | 1d | 11d |  | start no earlier than 2002-06-18 | 项目小组 |
| 45 | 测量系统评价 | 6d | 2002-06-19 | 2002-06-25 |  | 2002-06-19 | 2002-06-23 | 4d | 7d |  | start no earlier than 2002-06-19 | 郭圣妍 |
| 46 | 初始过程能力研究 | 6d | 2002-06-19 | 2002-06-25 |  | 2002-06-28 | 2002-06-28 | 1d? | 7d |  | start no earlier than 2002-06-19 | 蒋伟东 |
| 47 | 生产件批准 | 3d | 2002-07-01 | 2002-07-03 |  | 2002-06-28 | 2002-06-28 | 1d? | 0d |  | start no earlier than 2002-07-01 | 顾江龙 |
| 48 | 生产确认试验 | 42d | 2002-05-08 | 2002-06-27 |  |  |  |  | 5d |  | start no earlier than 2002-05-08 | 蒋伟东 |
| 49 | 包装评价 | 2d | 2002-07-01 | 2002-07-02 |  | 2002-06-28 | 2002-06-28 | 1d? | 1d |  | start no earlier than 2002-07-01 | 张燕 |
| 50 | 生产控制计划 | 4d | 2002-06-27 | 2002-07-01 |  | 2002-06-28 | 2002-06-28 | 1d? | 2d |  | finish no earlier than 2002-07-01 | 项目小组 |
| 51 | 产品质量先期策划认定和管理者支持 | 2d | 2002-06-30 | 2002-07-01 |  | 2002-06-28 | 2002-06-28 | 1d? | 2d |  | finish no earlier than 2002-07-01 | 项目小组 |
| 52 | 五.反馈\评定和纠正措施 | 1d? | 2002-07-01 | 2002-07-01 |  | 2002-06-28 | 2002-06-28 | 1d? | 2d |  | finish no earlier than 2002-07-01 |  |
| 53 | 减少变差 | 1d? | 2002-07-01 | 2002-07-01 |  |  |  |  | 2d |  | start no earlier than 2002-07-01 |  |
| 54 | 顾客满意 | 1d? | 2002-07-01 | 2002-07-01 |  | 2002-06-28 | 2002-06-28 | 1d? | 2d |  | finish no earlier than 2002-07-01 |  |
| 55 | 交付和服务 | 1d? | 2002-07-01 | 2002-07-01 |  | 2002-06-28 | 2002-06-28 | 1d? | 2d |  | finish no earlier than 2002-07-01 |  |
| 56 | 持续改进 | 1d? | 2002-07-01 | 2002-07-01 |  |  |  |  | 2d |  | start no earlier than 2002-07-01 |  |
