# APQP计划二

Schedule from MS Project, 2002-04-28 to 2002-10-18.
合力

## Calendars

- 标准: Mon-Fri 08:00-12:00, 13:00-17:00; Sat-Sun off. Exceptions (off unless hours are given): 2002-04-27 to 2002-04-28 08:00-12:00, 13:00-17:00, 2002-05-25 08:00-12:00, 13:00-17:00, 2002-06-01 08:00-12:00, 13:00-17:00, 2002-06-15 to 2002-06-16 08:00-12:00, 13:00-17:00, 2002-06-23 08:00-12:00, 13:00-17:00, 2002-06-30 08:00-12:00, 13:00-17:00, 2002-08-17 08:00-12:00, 13:00-17:00.

## Schedule

| ID | Task | Duration | Start | Finish | Predecessors | Baseline start | Baseline finish | Baseline duration | Total slack | Free slack | Constraint | Text1 |
| --- | --- | --- | --- | --- | --- | --- | --- | --- | --- | --- | --- | --- |
| 1 | 一.计划与确定项目 | 10d | 2002-04-28 | 2002-05-09 |  | 2002-04-15 | 2002-04-26 | 10d | 123d |  | start no earlier than 2002-04-28 |  |
| 2 | 识别顾客需求 | 1d | 2002-04-28 | 2002-04-28 |  | 2002-04-15 | 2002-04-15 | 1d | 132d |  | start no earlier than 2002-04-28 | 姚晓君 |
| 3 | 可行性分析 | 1d | 2002-04-28 | 2002-04-28 |  | 2002-04-15 | 2002-04-16 | 2d | 132d |  | start no earlier than 2002-04-28 | 小组 |
| 4 | 成立项目小组 | 1d | 2002-04-28 | 2002-04-28 |  |  |  |  | 127d | 0d | start no earlier than 2002-04-28 | 项目小组 |
| 5 | 编制APQP实施计划 | 1d | 2002-04-29 | 2002-04-29 | 4 |  |  |  | 127d | 0d | start no earlier than 2002-04-28 | 项目小组 |
| 6 | 设计任务书 | 2d | 2002-04-30 | 2002-05-01 | 5 | 2002-04-17 | 2002-04-17 | 1d | 127d | 0d | start no earlier than 2002-04-28 | 顾江龙 |
| 7 | 初始材料清单 | 2d | 2002-05-02 | 2002-05-03 | 6 | 2002-04-18 | 2002-04-18 | 1d | 127d |  | start no earlier than 2002-04-28 | 张燕 |
| 8 | 初始过程流程图 | 3d | 2002-05-03 | 2002-05-07 |  | 2002-04-19 | 2002-04-22 | 2d | 125d |  | start no earlier than 2002-05-03 | 张燕 |
| 9 | 设备、工装、量具、试验装置初始清单 | 2d | 2002-05-06 | 2002-05-07 |  |  |  |  | 125d |  | start no earlier than 2002-05-06 | 顾江龙 |
| 10 | 产品和过程特殊特性初始清单 | 2d | 2002-05-06 | 2002-05-07 |  | 2002-04-23 | 2002-04-24 | 2d | 125d |  | start no earlier than 2002-05-06 | 顾江龙 |
| 11 | 产品采购计划 | 2d | 2002-05-06 | 2002-05-07 |  |  |  |  | 125d |  | start no earlier than 2002-05-06 | 缪志军 |
| 12 | 产品保证计划 | 1d | 2002-05-07 | 2002-05-07 |  | 2002-04-25 | 2002-04-26 | 2d | 125d |  | start no earlier than 2002-05-07 | 项目小组 |
| 13 | 项目可行性评估 | 1d | 2002-05-08 | 2002-05-08 |  |  |  |  | 124d |  | start no earlier than 2002-05-08 | 项目小组 |
| 14 | 阶段总结和管理者支持 | 1d | 2002-05-09 | 2002-05-09 |  | 2002-04-26 | 2002-04-26 | 1d | 83d | 0d | start no earlier than 2002-05-09 | 项目小组 |
| 15 | 二.产品设计和开发 | 40d | 2002-05-10 | 2002-06-27 | 14 | 2002-04-27 | 2002-05-16 | 15d | 83d |  | finish no earlier than 2002-06-27 |  |
| 16 | DFMEA | 6d | 2002-05-10 | 2002-05-17 |  | 2002-04-27 | 2002-05-06 | 7d | 117d |  | start no earlier than 2002-05-10 | 项目小组 |
| 17 | 图纸绘制 | 8d | 2002-05-13 | 2002-05-22 |  | 2002-04-29 | 2002-05-03 | 5d | 112d | 0d | start no earlier than 2002-05-13 | 顾江龙 |
| 18 | 设计验证 | 1d | 2002-05-23 | 2002-05-23 | 17 | 2002-05-03 | 2002-05-06 | 2d | 112d | 0d | start no earlier than 2002-05-10 | 项目小组 |
| 19 | 设计评审 | 1d | 2002-05-24 | 2002-05-24 | 18 | 2002-05-07 | 2002-05-08 | 2d | 112d |  | start no earlier than 2002-05-10 | 项目小组 |
| 20 | 样件控制计划 | 5d | 2002-05-15 | 2002-05-21 |  |  |  |  | 115d |  | start no earlier than 2002-05-15 | 项目小组 |
| 21 | 工程样件制造 | 1d | 2002-05-22 | 2002-05-22 |  | 2002-05-09 | 2002-05-13 | 3d | 114d |  | start no earlier than 2002-05-22 | 项目小组 |
| 22 | 材料清单 | 2d | 2002-05-17 | 2002-05-20 |  | 2002-05-10 | 2002-05-14 | 3d | 116d |  | start no earlier than 2002-05-17 | 张燕 |
| 23 | 产品和过程特殊特性清单 | 2d | 2002-05-17 | 2002-05-20 |  | 2002-05-15 | 2002-05-16 | 2d | 89d | 0d | start no earlier than 2002-05-17 | 张燕 |
| 24 | 新设备、工装和设施要求 | 1d | 2002-05-21 | 2002-05-21 | 23 | 2002-05-17 | 2002-05-22 | 4d | 89d | 0d | start no earlier than 2002-05-17 | 张燕 |
| 25 | 新设备、工装和设施采购 | 26d | 2002-05-22 | 2002-06-20 | 24 |  |  |  | 89d |  | start no earlier than 2002-05-10 | 缪志军 |
| 26 | 量具和试验设备要求 | 1d | 2002-05-10 | 2002-05-10 |  | 2002-05-23 | 2002-05-23 | 1d | 122d |  | start no earlier than 2002-05-10 | 张燕 |
| 27 | 量具和试验设备采购 | 15d | 2002-05-23 | 2002-06-10 |  |  |  |  | 99d |  | start no earlier than 2002-05-23 | 缪志军 |
| 28 | 工装（OTS)样件制作、提交（认可） | 3d | 2002-06-24 | 2002-06-26 |  |  |  |  | 84d |  | start no earlier than 2002-06-24 | 顾江龙 |
| 29 | 小组可行性承诺及管理者支持 | 1d | 2002-06-28 | 2002-06-28 |  | 2002-05-24 | 2002-05-24 | 1d | 82d |  | start no earlier than 2002-06-28 | 项目小组 |
| 30 | 三.过程设计及开发 | 37d | 2002-07-01 | 2002-08-19 |  | 2002-05-27 | 2002-06-17 | 19d | 44d |  | start no earlier than 2002-07-01 |  |
| 31 | 包装标准 | 2d | 2002-07-01 | 2002-07-02 |  | 2002-06-01 | 2002-06-01 | 1d | 79d |  | start no earlier than 2002-07-01 | 张燕 |
| 32 | 产品/过程质量体系评审 | 2d | 2002-07-03 | 2002-07-04 |  |  |  |  | 77d |  | start no earlier than 2002-07-03 | 姚晓君 |
| 33 | 过程流程图 | 4d | 2002-07-04 | 2002-07-09 |  | 2002-06-03 | 2002-06-07 | 5d | 74d |  | start no earlier than 2002-07-04 | 张燕 |
| 34 | 场地平面布局图 | 3d | 2002-07-09 | 2002-07-11 |  | 2002-06-05 | 2002-06-06 | 2d | 72d |  | start no earlier than 2002-07-09 | 陆耀平 |
| 35 | 特性矩阵图 | 3d | 2002-07-10 | 2002-07-12 |  |  |  |  | 71d |  | start no earlier than 2002-07-10 | 陆耀平 |
| 36 | PFMEA | 13d | 2002-07-12 | 2002-07-30 |  | 2002-06-01 | 2002-06-13 | 10d | 59d |  | start no earlier than 2002-07-12 | 项目小组 |
| 37 | 试生产控制计划 | 6d | 2002-08-01 | 2002-08-08 |  | 2002-06-04 | 2002-06-13 | 8d | 52d |  | start no earlier than 2002-08-01 | 项目小组 |
| 38 | 工艺过程控制卡 | 5d | 2002-08-08 | 2002-08-14 |  | 2002-06-06 | 2002-06-15 | 8d | 48d |  | start no earlier than 2002-08-08 | 张燕 |
| 39 | 测量系统分析计划 | 1d | 2002-08-15 | 2002-08-15 |  | 2002-06-13 | 2002-06-14 | 2d | 46d | 1d | start no earlier than 2002-08-15 | 郭圣妍 |
| 40 | 初始过程能力研究计划 | 1d | 2002-08-17 | 2002-08-17 | 39 | 2002-06-15 | 2002-06-16 | 2d | 45d |  | start no earlier than 2002-08-17 | 蒋伟东 |
| 41 | 包装规范 | 1d | 2002-08-19 | 2002-08-19 |  | 2002-06-16 | 2002-06-16 | 1d | 44d |  | start no earlier than 2002-08-19 | 张燕 |
| 42 | 阶段总结和管理者支持 | 1d | 2002-08-19 | 2002-08-19 |  | 2002-06-17 | 2002-06-17 | 1d | 44d |  | start no earlier than 2002-08-19 | 项目小组 |
| 43 | 四.产品和过程确认 | 11d | 2002-08-20 | 2002-09-03 |  | 2002-06-18 | 2002-06-28 | 10d | 33d |  | start no earlier than 2002-08-20 |  |
| 44 | 试生产 | 3d | 2002-08-20 | 2002-08-22 |  | 2002-06-18 | 2002-06-18 | 1d | 41d |  | start no earlier than 2002-08-20 | 项目小组 |
| 45 | 测量系统评价 | 5d | 2002-08-20 | 2002-08-26 |  | 2002-06-19 | 2002-06-23 | 4d | 39d |  | start no earlier than 2002-08-20 | 郭圣妍 |
| 46 | 初始过程能力研究 | 6d | 2002-08-20 | 2002-08-27 |  | 2002-06-28 | 2002-06-28 | 1d? | 38d |  | start no earlier than 2002-08-20 | 蒋伟东 |
| 47 | 生产件批准 | 3d | 2002-08-28 | 2002-08-30 |  | 2002-06-28 | 2002-06-28 | 1d? | 35d |  | start no earlier than 2002-08-28 | 顾江龙 |
| 48 | 生产确认试验 | 42d | 2002-08-22 | 2002-10-18 |  |  |  |  | 0d |  | start no earlier than 2002-08-22 | 蒋伟东 |
| 49 | 包装评价 | 2d | 2002-08-23 | 2002-08-26 |  | 2002-06-28 | 2002-06-28 | 1d? | 39d |  | start no earlier than 2002-08-23 | 张燕 |
| 50 | 生产控制计划 | 4d | 2002-08-26 | 2002-08-29 |  | 2002-06-28 | 2002-06-28 | 1d? | 36d |  | start no earlier than 2002-08-26 | 项目小组 |
| 51 | 产品质量先期策划认定和管理者支持 | 2d | 2002-09-02 | 2002-09-03 |  | 2002-06-28 | 2002-06-28 | 1d? | 33d |  | start no earlier than 2002-09-01 | 项目小组 |
| 52 | 五.反馈\评定和纠正措施 | 1d? | 2002-09-03 | 2002-09-03 |  | 2002-06-28 | 2002-06-28 | 1d? | 33d |  | start no earlier than 2002-09-03 |  |
| 53 | 减少变差 | 1d? | 2002-09-03 | 2002-09-03 |  |  |  |  | 33d |  | start no earlier than 2002-09-03 |  |
| 54 | 顾客满意 | 1d? | 2002-09-03 | 2002-09-03 |  | 2002-06-28 | 2002-06-28 | 1d? | 33d |  | start no earlier than 2002-09-03 |  |
| 55 | 交付和服务 | 1d? | 2002-09-03 | 2002-09-03 |  | 2002-06-28 | 2002-06-28 | 1d? | 33d |  | start no earlier than 2002-09-03 |  |
| 56 | 持续改进 | 1d? | 2002-09-03 | 2002-09-03 |  |  |  |  | 33d |  | start no earlier than 2002-09-03 |  |
